# Enrollment & Claims Platform Modernization

Schedule from MS Project XML, 2026-07-28 to 2027-11-02.
ACME Company

## Calendars

- Standard: Mon-Fri 08:00-17:00; Sat-Sun off.

## Resources

| Resource |
| --- |
| C. Tyrrell |
| F. Jones |
| G. Fenwick |
| N. Sharma |
| W. Donnelly |
| J. Albert |
| M. Alvarez |
| T. McCormick |
| D. Okafor |
| S. Lindqvist |
| K. Delgado |
| P. Novak |
| A. Reyes |
| B. Sato |
| P. Sundaram |
| R. Whitfield |
| V. Alaoui |
| E. Kowalski |
| L. Bergström |
| H. Osei |

## Schedule

| ID | WBS | Task | Duration | Start | Finish | Predecessors | Resources |
| --- | --- | --- | --- | --- | --- | --- | --- |
| 1 | 1 | **Initiation & Requirements** | 71d | 2026-07-28 | 2026-11-03 |  |  |
| 2 | 1.1 | **Project Charter & Business Case** | 5d | 2026-07-28 | 2026-08-03 |  |  |
| 3 | 1.1.1 | Draft business case & objectives | 2d | 2026-07-28 | 2026-07-29 |  | C. Tyrrell |
| 4 | 1.1.2 | Identify executive sponsor & governance structure | 1d | 2026-07-30 | 2026-07-30 | 3 | C. Tyrrell |
| 5 | 1.1.3 | Define high-level scope & success criteria | 1d | 2026-07-31 | 2026-07-31 | 4 | C. Tyrrell |
| 6 | 1.1.4 | Charter review & executive sign-off | 1d | 2026-08-03 | 2026-08-03 | 5 | C. Tyrrell |
| 7 | 1.1B | **Project Kickoff Meeting** | 1d | 2026-08-04 | 2026-08-04 | 2 |  |
| 8 | 1.1B.1 | Prepare kickoff deck (scope, team, milestones) | 1d | 2026-08-04 | 2026-08-04 |  | C. Tyrrell |
| 9 | 1.1B.2 | Conduct kickoff meeting with steering committee & core team | 1d | 2026-08-04 | 2026-08-04 |  | C. Tyrrell |
| 10 | 1.2 | **Stakeholder Requirements Gathering** | 15d | 2026-08-05 | 2026-08-25 | 7 |  |
| 11 | 1.2.1 | Identify stakeholder groups | 1d | 2026-08-05 | 2026-08-05 |  | F. Jones |
| 12 | 1.2.2 | Requirements workshops — Underwriting | 2d | 2026-08-06 | 2026-08-07 | 11 | F. Jones |
| 13 | 1.2.3 | Requirements workshops — Claims Administration | 2d | 2026-08-10 | 2026-08-11 | 12 | F. Jones |
| 14 | 1.2.4 | Requirements workshops — Billing & Finance | 2d | 2026-08-12 | 2026-08-13 | 13 | F. Jones |
| 15 | 1.2.5 | Requirements workshops — Compliance/Legal | 2d | 2026-08-14 | 2026-08-17 | 14 | F. Jones |
| 16 | 1.2.6 | Requirements workshops — Customer Service & New Business | 2d | 2026-08-18 | 2026-08-19 | 15 | F. Jones |
| 17 | 1.2.7 | Document functional requirements | 2d | 2026-08-20 | 2026-08-21 | 16 | F. Jones |
| 18 | 1.2.8 | Document non-functional requirements (security, performance, compliance) | 1d | 2026-08-24 | 2026-08-24 | 17 | F. Jones |
| 19 | 1.2.9 | Build requirements traceability matrix | 1d | 2026-08-25 | 2026-08-25 | 18 | F. Jones |
| 20 | 1.2B | **SOX Control Impact Assessment** | 5d | 2026-08-26 | 2026-09-01 | 10 |  |
| 21 | 1.2B.1 | Identify SOX-relevant systems & financial data flows | 2d | 2026-08-26 | 2026-08-27 |  | G. Fenwick |
| 22 | 1.2B.2 | Assess control impact of upgrade, conversions & integrations | 2d | 2026-08-28 | 2026-08-31 | 21 | G. Fenwick |
| 23 | 1.2B.3 | Document required control changes & obtain Internal Audit input | 1d | 2026-09-01 | 2026-09-01 | 22 | G. Fenwick |
| 24 | 1.2C | **Data Privacy / PII Impact Assessment** | 5d | 2026-08-26 | 2026-09-01 |  |  |
| 25 | 1.2C.1 | Identify PII/PHI data elements in scope (member, provider, claims) | 2d | 2026-08-26 | 2026-08-27 |  | N. Sharma |
| 26 | 1.2C.2 | Assess privacy/regulatory impact of conversions & integrations | 2d | 2026-08-28 | 2026-08-31 | 25 | N. Sharma |
| 27 | 1.2C.3 | Document required privacy controls & sign-off | 1d | 2026-09-01 | 2026-09-01 | 26 | N. Sharma |

| ID | WBS | Task | Duration | Start | Finish | Predecessors | Resources |
| --- | --- | --- | --- | --- | --- | --- | --- |
| 28 | 1.3 | **Vendor Selection — Platform Upgrade** | 14d | 2026-09-02 | 2026-09-21 | 24 |  |
| 29 | 1.3.0 | Draft RFP document (Platform Upgrade) | 2d | 2026-09-02 | 2026-09-03 |  | W. Donnelly |
| 30 | 1.3.1 | Define vendor evaluation criteria | 1d | 2026-09-04 | 2026-09-04 | 29 | W. Donnelly |
| 31 | 1.3.2 | Issue RFP to platform vendors | 1d | 2026-09-07 | 2026-09-07 | 30 | W. Donnelly |
| 32 | 1.3.3 | Vendor demos & Q&A sessions | 3d | 2026-09-08 | 2026-09-10 | 31 | W. Donnelly |
| 33 | 1.3.4 | Score vendor responses | 2d | 2026-09-11 | 2026-09-14 | 32 | W. Donnelly |
| 34 | 1.3.5 | Reference checks | 1d | 2026-09-15 | 2026-09-15 | 33 | W. Donnelly |
| 35 | 1.3.6 | Contract negotiation | 2d | 2026-09-16 | 2026-09-17 | 34 | W. Donnelly |
| 36 | 1.3.7 | Draft & finalize SOW with selected platform vendor | 2d | 2026-09-18 | 2026-09-21 | 35 | W. Donnelly |
| 37 | 1.4 | **Vendor Selection — Integration Middleware** | 14d | 2026-09-02 | 2026-09-21 |  |  |
| 38 | 1.4.0 | Draft RFP document (Integration Middleware) | 2d | 2026-09-02 | 2026-09-03 |  | W. Donnelly |
| 39 | 1.4.1 | Define integration architecture requirements | 2d | 2026-09-04 | 2026-09-07 | 38 | W. Donnelly |
| 40 | 1.4.2 | Issue RFP to middleware vendors | 1d | 2026-09-08 | 2026-09-08 | 39 | W. Donnelly |
| 41 | 1.4.3 | Vendor demos & technical evaluation | 3d | 2026-09-09 | 2026-09-11 | 40 | W. Donnelly |
| 42 | 1.4.4 | Score vendor responses | 2d | 2026-09-14 | 2026-09-15 | 41 | W. Donnelly |
| 43 | 1.4.5 | Contract negotiation | 2d | 2026-09-16 | 2026-09-17 | 42 | W. Donnelly |
| 44 | 1.4.6 | Draft & finalize SOW with selected middleware vendor | 2d | 2026-09-18 | 2026-09-21 | 43 | W. Donnelly |
| 45 | 1.5 | **Requirements Sign-off** | 8d | 2026-09-22 | 2026-10-01 | 37 |  |
| 46 | 1.5.1 | Requirements walkthrough with SMEs & business owners | 1d | 2026-09-22 | 2026-09-22 |  | F. Jones |
| 47 | 1.5.2 | SME & business owner feedback period | 3d | 2026-09-23 | 2026-09-25 | 46 | F. Jones |
| 48 | 1.5.3 | Recirculate updated requirements for review | 1d | 2026-09-28 | 2026-09-28 | 47 | F. Jones |
| 49 | 1.5.4 | Final review & formal sign-off | 3d | 2026-09-29 | 2026-10-01 | 48 | F. Jones |
| 50 | 1.6 | **Solution Architecture & Design** | 15d | 2026-10-02 | 2026-10-22 | 45 |  |
| 51 | 1.6.1 | Define target-state architecture | 3d | 2026-10-02 | 2026-10-06 |  | J. Albert |
| 52 | 1.6.2 | Design data conversion approach | 2d | 2026-10-07 | 2026-10-08 | 51 | J. Albert |
| 53 | 1.6.3 | Design integration architecture (API/file-based) | 3d | 2026-10-09 | 2026-10-13 | 52 | J. Albert |
| 54 | 1.6.4 | Design security & access model | 2d | 2026-10-14 | 2026-10-15 | 53 | J. Albert |
| 55 | 1.6.5 | Design disaster recovery/failover approach | 2d | 2026-10-16 | 2026-10-19 | 54 | J. Albert |
| 56 | 1.6.6 | Technical design walkthroughs with stakeholders | 2d | 2026-10-20 | 2026-10-21 | 55 | J. Albert |
| 57 | 1.6.7 | Finalize design documentation | 1d | 2026-10-22 | 2026-10-22 | 56 | J. Albert |

| ID | WBS | Task | Duration | Start | Finish | Predecessors | Resources |
| --- | --- | --- | --- | --- | --- | --- | --- |
| 58 | 1.7 | **Design Sign-off (incl. Compliance/Legal Review)** | 8d | 2026-10-23 | 2026-11-03 | 50 |  |
| 59 | 1.7.1 | Architecture & design walkthrough with SMEs & business owners | 1d | 2026-10-23 | 2026-10-23 |  | J. Albert |
| 60 | 1.7.2 | SME & business owner feedback period | 3d | 2026-10-26 | 2026-10-28 | 59 | J. Albert |
| 61 | 1.7.3 | Recirculate updated design documents for review | 1d | 2026-10-29 | 2026-10-29 | 60 | J. Albert |
| 62 | 1.7.4 | Final review & formal design sign-off | 3d | 2026-10-30 | 2026-11-03 | 61 | J. Albert |
| 63 | 2 | **System Upgrade** | 45d | 2026-11-04 | 2027-01-05 | 1 |  |
| 64 | 2.1 | **Environment Provisioning** | 10d | 2026-11-04 | 2026-11-17 |  |  |
| 65 | 2.1.1 | Provision infrastructure (servers/cloud environment) | 3d | 2026-11-04 | 2026-11-06 |  | M. Alvarez |
| 66 | 2.1.2 | Configure network & security groups | 2d | 2026-11-09 | 2026-11-10 | 65 | M. Alvarez |
| 67 | 2.1.3 | Install base platform software | 3d | 2026-11-11 | 2026-11-13 | 66 | M. Alvarez |
| 68 | 2.1.4 | Configure environment monitoring & logging | 2d | 2026-11-16 | 2026-11-17 | 67 | M. Alvarez |
| 69 | 2.2 | **Core Platform Upgrade / Migration** | 20d | 2026-11-18 | 2026-12-15 | 64 |  |
| 70 | 2.2.1 | Backup current production environment | 1d | 2026-11-18 | 2026-11-18 |  | M. Alvarez |
| 71 | 2.2.2 | Apply platform upgrade — Dev environment | 4d | 2026-11-19 | 2026-11-24 | 70 | M. Alvarez |
| 72 | 2.2.3 | Smoke test Dev environment | 2d | 2026-11-25 | 2026-11-26 | 71 | M. Alvarez |
| 73 | 2.2.4 | Apply platform upgrade — Test environment | 4d | 2026-11-27 | 2026-12-02 | 72 | M. Alvarez |
| 74 | 2.2.5 | Smoke test Test environment | 2d | 2026-12-03 | 2026-12-04 | 73 | M. Alvarez |
| 75 | 2.2.6 | Apply platform upgrade — Staging environment | 4d | 2026-12-07 | 2026-12-10 | 74 | M. Alvarez |
| 76 | 2.2.7 | Configuration & parameter tuning | 3d | 2026-12-11 | 2026-12-15 | 75 | M. Alvarez |
| 77 | 2.3 | **Regression Testing (Existing Functionality)** | 10d | 2026-12-16 | 2026-12-29 | 69 |  |
| 78 | 2.3.1 | Execute regression suite — core functions | 4d | 2026-12-16 | 2026-12-21 |  | M. Alvarez |
| 79 | 2.3.2 | Execute regression suite — reporting functions | 3d | 2026-12-22 | 2026-12-24 | 78 | M. Alvarez |
| 80 | 2.3.3 | Log & triage defects | 2d | 2026-12-25 | 2026-12-28 | 79 | M. Alvarez |
| 81 | 2.3.4 | Retest resolved defects | 1d | 2026-12-29 | 2026-12-29 | 80 | M. Alvarez |

| ID | WBS | Task | Duration | Start | Finish | Predecessors | Resources |
| --- | --- | --- | --- | --- | --- | --- | --- |
| 82 | 2.4 | **Upgrade Validation & Sign-off** | 5d | 2026-12-30 | 2027-01-05 | 77 |  |
| 83 | 2.4.1 | Performance benchmarking vs. baseline | 2d | 2026-12-30 | 2026-12-31 |  | M. Alvarez |
| 84 | 2.4.2 | Business stakeholder validation | 2d | 2027-01-01 | 2027-01-04 | 83 | M. Alvarez |
| 85 | 2.4.3 | Formal upgrade sign-off | 1d | 2027-01-05 | 2027-01-05 | 84 | M. Alvarez |
| 86 | 3 | **Data Conversion** | 50d | 2027-01-06 | 2027-03-16 | 63 |  |
| 87 | 3.1 | **Data Mapping — Member/Policy Data** | 10d | 2027-01-06 | 2027-01-19 |  |  |
| 88 | 3.1.1 | Inventory source data fields | 2d | 2027-01-06 | 2027-01-07 |  | T. McCormick |
| 89 | 3.1.2 | Identify target system field requirements | 2d | 2027-01-08 | 2027-01-11 | 88 | T. McCormick |
| 90 | 3.1.3 | Build field-level mapping document | 3d | 2027-01-12 | 2027-01-14 | 89 | T. McCormick |
| 91 | 3.1.4 | Identify data quality issues in source | 1d | 2027-01-15 | 2027-01-15 | 90 | T. McCormick |
| 92 | 3.1.5 | Define transformation rules | 1d | 2027-01-18 | 2027-01-18 | 91 | T. McCormick |
| 93 | 3.1.6 | Business SME review & sign-off | 1d | 2027-01-19 | 2027-01-19 | 92 | T. McCormick |
| 94 | 3.2 | **Data Mapping — Provider/Producer Data** | 10d | 2027-01-06 | 2027-01-19 |  |  |
| 95 | 3.2.1 | Inventory source provider/producer fields | 2d | 2027-01-06 | 2027-01-07 |  | T. McCormick |
| 96 | 3.2.2 | Identify target system field requirements | 2d | 2027-01-08 | 2027-01-11 | 95 | T. McCormick |
| 97 | 3.2.3 | Build field-level mapping document | 3d | 2027-01-12 | 2027-01-14 | 96 | T. McCormick |
| 98 | 3.2.4 | Identify data quality issues | 1d | 2027-01-15 | 2027-01-15 | 97 | T. McCormick |
| 99 | 3.2.5 | Define transformation rules | 1d | 2027-01-18 | 2027-01-18 | 98 | T. McCormick |
| 100 | 3.2.6 | Business SME review & sign-off | 1d | 2027-01-19 | 2027-01-19 | 99 | T. McCormick |
| 101 | 3.3 | **Data Mapping — Historical Claims** | 15d | 2027-01-06 | 2027-01-26 |  |  |
| 102 | 3.3.1 | Inventory source claims data fields | 2d | 2027-01-06 | 2027-01-07 |  | T. McCormick |
| 103 | 3.3.2 | Identify target system field requirements | 2d | 2027-01-08 | 2027-01-11 | 102 | T. McCormick |
| 104 | 3.3.3 | Build field-level mapping document | 4d | 2027-01-12 | 2027-01-15 | 103 | T. McCormick |
| 105 | 3.3.4 | Identify data quality issues (large historical volume) | 3d | 2027-01-18 | 2027-01-20 | 104 | T. McCormick |
| 106 | 3.3.5 | Define transformation rules | 2d | 2027-01-21 | 2027-01-22 | 105 | T. McCormick |
| 107 | 3.3.6 | Business SME review & sign-off | 2d | 2027-01-25 | 2027-01-26 | 106 | T. McCormick |

| ID | WBS | Task | Duration | Start | Finish | Predecessors | Resources |
| --- | --- | --- | --- | --- | --- | --- | --- |
| 108 | 3.4 | **Conversion Build & Cleansing** | 20d | 2027-01-27 | 2027-02-23 | 101 |  |
| 109 | 3.4.1 | Build extract scripts (source system) | 4d | 2027-01-27 | 2027-02-01 |  | T. McCormick |
| 110 | 3.4.2 | **Build cleansing/scrubbing rules** | 5d | 2027-02-02 | 2027-02-08 | 109 |  |
| 111 | 3.4.2.1 | Define null-handling rules | 1d | 2027-02-02 | 2027-02-02 |  | T. McCormick |
| 112 | 3.4.2.2 | Define deduplication rules | 1d | 2027-02-03 | 2027-02-03 | 111 | T. McCormick |
| 113 | 3.4.2.3 | Define standardization rules (formats, codes) | 1d | 2027-02-04 | 2027-02-04 | 112 | T. McCormick |
| 114 | 3.4.2.4 | Build cleansing scripts | 1d | 2027-02-05 | 2027-02-05 | 113 | T. McCormick |
| 115 | 3.4.2.5 | Unit test cleansing scripts | 1d | 2027-02-08 | 2027-02-08 | 114 | T. McCormick |
| 116 | 3.4.3 | Build transformation logic | 5d | 2027-02-09 | 2027-02-15 | 110 | T. McCormick |
| 117 | 3.4.4 | Build load scripts (target system) | 4d | 2027-02-16 | 2027-02-19 | 116 | T. McCormick |
| 118 | 3.4.5 | Unit test conversion scripts | 1d | 2027-02-22 | 2027-02-22 | 117 | T. McCormick |
| 119 | 3.4.6 | Peer/technical review of conversion code | 1d | 2027-02-23 | 2027-02-23 | 118 | T. McCormick |
| 120 | 3.5 | **Conversion Dry Run 1** | 5d | 2027-02-24 | 2027-03-02 | 108 |  |
| 121 | 3.5.1 | Execute full extract from source | 1d | 2027-02-24 | 2027-02-24 |  | T. McCormick |
| 122 | 3.5.2 | Execute cleansing & transformation pass | 1d | 2027-02-25 | 2027-02-25 | 121 | T. McCormick |
| 123 | 3.5.3 | Execute load into target (test environment) | 1d | 2027-02-26 | 2027-02-26 | 122 | T. McCormick |
| 124 | 3.5.4 | Record volume/counts (source vs. loaded) | 1d | 2027-03-01 | 2027-03-01 | 123 | T. McCormick |
| 125 | 3.5.5 | Identify failed records & log defects | 1d | 2027-03-02 | 2027-03-02 | 124 | T. McCormick |
| 126 | 3.6 | **Conversion Dry Run 2 (post-fixes)** | 5d | 2027-03-03 | 2027-03-09 | 120 |  |
| 127 | 3.6.1 | Apply defect fixes from Dry Run 1 | 2d | 2027-03-03 | 2027-03-04 |  | T. McCormick |
| 128 | 3.6.2 | Re-execute extract, transform, load | 2d | 2027-03-05 | 2027-03-08 | 127 | T. McCormick |
| 129 | 3.6.3 | Validate fixes resolved | 1d | 2027-03-09 | 2027-03-09 | 128 | T. McCormick |
| 130 | 3.7 | **Data Reconciliation & Sign-off** | 5d | 2027-03-10 | 2027-03-16 | 126 |  |
| 131 | 3.7.1 | Run reconciliation reports (source vs. target) | 1d | 2027-03-10 | 2027-03-10 |  | T. McCormick |
| 132 | 3.7.2 | Spot-check sample records for accuracy | 1d | 2027-03-11 | 2027-03-11 | 131 | T. McCormick |
| 133 | 3.7.3 | Business SME validation of converted data | 1d | 2027-03-12 | 2027-03-12 | 132 | T. McCormick |
| 134 | 3.7.4 | Document known exceptions/variances | 1d | 2027-03-15 | 2027-03-15 | 133 | T. McCormick |
| 135 | 3.7.5 | Formal sign-off (Conversion Lead & Business Owner) | 1d | 2027-03-16 | 2027-03-16 | 134 | T. McCormick |

| ID | WBS | Task | Duration | Start | Finish | Predecessors | Resources |
| --- | --- | --- | --- | --- | --- | --- | --- |
| 136 | 4 | **Integration Build (Agile)** | 90d | 2027-01-06 | 2027-05-11 |  |  |
| 137 | 4.1 | **Billing Integration — Sprints 1-2** | 20d | 2027-01-06 | 2027-02-02 |  |  |
| 138 | 4.1.1 | Interface design & spec review | 4d | 2027-01-06 | 2027-01-11 |  | D. Okafor |
| 139 | 4.1.2 | **Build inbound interface (Billing → Platform)** | 5d | 2027-01-12 | 2027-01-18 | 138 |  |
| 140 | 4.1.2.1 | Define message schema/payload | 1d | 2027-01-12 | 2027-01-12 |  | D. Okafor |
| 141 | 4.1.2.2 | Build listener/endpoint | 1d | 2027-01-13 | 2027-01-13 | 140 | D. Okafor |
| 142 | 4.1.2.3 | Build field mapping & transformation logic | 2d | 2027-01-14 | 2027-01-15 | 141 | D. Okafor |
| 143 | 4.1.2.4 | Code review | 1d | 2027-01-18 | 2027-01-18 | 142 | D. Okafor |
| 144 | 4.1.3 | Build outbound interface (Platform → Billing) | 5d | 2027-01-19 | 2027-01-25 | 139 | D. Okafor |
| 145 | 4.1.4 | Unit test interface endpoints | 2d | 2027-01-26 | 2027-01-27 | 144 | D. Okafor |
| 146 | 4.1.5 | Sprint 1 review/demo | 1d | 2027-01-28 | 2027-01-28 | 145 | D. Okafor |
| 147 | 4.1.6 | Error handling & performance testing | 2d | 2027-01-29 | 2027-02-01 | 146 | D. Okafor |
| 148 | 4.1.7 | Integration test w/ converted data & Sprint 2 review | 1d | 2027-02-02 | 2027-02-02 | 147 | D. Okafor |
| 149 | 4.2 | **Underwriting Integration — Sprints 1-2** | 20d | 2027-01-06 | 2027-02-02 |  |  |
| 150 | 4.2.1 | Interface design & spec review | 4d | 2027-01-06 | 2027-01-11 |  | S. Lindqvist |
| 151 | 4.2.2 | Build inbound interface (Underwriting → Platform) | 5d | 2027-01-12 | 2027-01-18 | 150 | S. Lindqvist |
| 152 | 4.2.3 | Build outbound interface (Platform → Underwriting) | 5d | 2027-01-19 | 2027-01-25 | 151 | S. Lindqvist |
| 153 | 4.2.4 | Unit test interface endpoints | 2d | 2027-01-26 | 2027-01-27 | 152 | S. Lindqvist |
| 154 | 4.2.5 | Sprint 1 review/demo | 1d | 2027-01-28 | 2027-01-28 | 153 | S. Lindqvist |
| 155 | 4.2.6 | Error handling & performance testing | 2d | 2027-01-29 | 2027-02-01 | 154 | S. Lindqvist |
| 156 | 4.2.7 | Integration test & Sprint 2 review | 1d | 2027-02-02 | 2027-02-02 | 155 | S. Lindqvist |
| 157 | 4.3 | **Claims Administration Integration — Sprints 3-4** | 20d | 2027-03-17 | 2027-04-13 |  |  |
| 158 | 4.3.1 | Interface design & spec review | 4d | 2027-03-17 | 2027-03-22 |  | K. Delgado |
| 159 | 4.3.2 | Build inbound interface (Claims → Platform) | 5d | 2027-03-23 | 2027-03-29 | 158 | K. Delgado |
| 160 | 4.3.3 | Build outbound interface (Platform → Claims) | 5d | 2027-03-30 | 2027-04-05 | 159 | K. Delgado |
| 161 | 4.3.4 | Unit test interface endpoints | 2d | 2027-04-06 | 2027-04-07 | 160 | K. Delgado |
| 162 | 4.3.5 | Sprint 3 review/demo | 1d | 2027-04-08 | 2027-04-08 | 161 | K. Delgado |
| 163 | 4.3.6 | Error handling & performance testing | 2d | 2027-04-09 | 2027-04-12 | 162 | K. Delgado |
| 164 | 4.3.7 | Integration test w/ converted claims data & Sprint 4 review | 1d | 2027-04-13 | 2027-04-13 | 163 | K. Delgado |

| ID | WBS | Task | Duration | Start | Finish | Predecessors | Resources |
| --- | --- | --- | --- | --- | --- | --- | --- |
| 165 | 4.4 | **Commission Management Integration — Sprints 3-4** | 20d | 2027-01-06 | 2027-02-02 |  |  |
| 166 | 4.4.1 | Interface design & spec review | 4d | 2027-01-06 | 2027-01-11 |  | P. Novak |
| 167 | 4.4.2 | Build inbound interface (Commission → Platform) | 5d | 2027-01-12 | 2027-01-18 | 166 | P. Novak |
| 168 | 4.4.3 | Build outbound interface (Platform → Commission) | 5d | 2027-01-19 | 2027-01-25 | 167 | P. Novak |
| 169 | 4.4.4 | Unit test interface endpoints | 2d | 2027-01-26 | 2027-01-27 | 168 | P. Novak |
| 170 | 4.4.5 | Sprint 3 review/demo | 1d | 2027-01-28 | 2027-01-28 | 169 | P. Novak |
| 171 | 4.4.6 | Error handling & performance testing | 2d | 2027-01-29 | 2027-02-01 | 170 | P. Novak |
| 172 | 4.4.7 | Integration test & Sprint 4 review | 1d | 2027-02-02 | 2027-02-02 | 171 | P. Novak |
| 173 | 4.5 | **Data Warehouse/Reporting Integration — Sprints 5-6** | 20d | 2027-04-14 | 2027-05-11 |  |  |
| 174 | 4.5.1 | Define reporting data model/schema | 4d | 2027-04-14 | 2027-04-19 |  | A. Reyes |
| 175 | 4.5.2 | Build ETL feed to Data Warehouse | 6d | 2027-04-20 | 2027-04-27 | 174 | A. Reyes |
| 176 | 4.5.3 | Build standard report templates | 4d | 2027-04-28 | 2027-05-03 | 175 | A. Reyes |
| 177 | 4.5.4 | Unit test ETL & reports | 2d | 2027-05-04 | 2027-05-05 | 176 | A. Reyes |
| 178 | 4.5.5 | Sprint 5 review/demo | 1d | 2027-05-06 | 2027-05-06 | 177 | A. Reyes |
| 179 | 4.5.6 | Performance testing (large data volume) | 2d | 2027-05-07 | 2027-05-10 | 178 | A. Reyes |
| 180 | 4.5.7 | Integration test & Sprint 6 review | 1d | 2027-05-11 | 2027-05-11 | 179 | A. Reyes |
| 181 | 4.6 | **Payment Processing Integration — Sprints 5-6** | 20d | 2027-02-03 | 2027-03-02 |  |  |
| 182 | 4.6.1 | Interface design & spec review | 4d | 2027-02-03 | 2027-02-08 |  | B. Sato |
| 183 | 4.6.2 | Build payment gateway connection | 5d | 2027-02-09 | 2027-02-15 | 182 | B. Sato |
| 184 | 4.6.3 | Build reconciliation/settlement logic | 5d | 2027-02-16 | 2027-02-22 | 183 | B. Sato |
| 185 | 4.6.4 | Unit test interface endpoints | 2d | 2027-02-23 | 2027-02-24 | 184 | B. Sato |
| 186 | 4.6.5 | Sprint 5 review/demo | 1d | 2027-02-25 | 2027-02-25 | 185 | B. Sato |
| 187 | 4.6.6 | Error handling & PCI compliance validation | 2d | 2027-02-26 | 2027-03-01 | 186 | B. Sato |
| 188 | 4.6.7 | Integration test & Sprint 6 review | 1d | 2027-03-02 | 2027-03-02 | 187 | B. Sato |

| ID | WBS | Task | Duration | Start | Finish | Predecessors | Resources |
| --- | --- | --- | --- | --- | --- | --- | --- |
| 189 | 5 | **Testing (Functional, System, UAT)** | 155d | 2027-01-06 | 2027-08-10 |  |  |
| 190 | 5.1 | **Functional Testing (ongoing, per sprint)** | 92d | 2027-01-06 | 2027-05-13 |  |  |
| 191 | 5.1.0 | Offshore QA Team Onboarding & Coordination Setup | 2d | 2027-01-06 | 2027-01-07 |  | P. Sundaram |
| 192 | 5.1.1 | Functional test planning & test case development | 10d | 2027-01-08 | 2027-01-21 | 191 | R. Whitfield |
| 193 | 5.1.2 | Functional testing — Billing & Payment integrations | 20d | 2027-01-22 | 2027-02-18 | 192 | P. Sundaram |
| 194 | 5.1.3 | Functional testing — Underwriting & Commission integrations | 20d | 2027-02-19 | 2027-03-18 | 193 | P. Sundaram |
| 195 | 5.1.4 | Functional testing — Claims & Data Warehouse integrations | 20d | 2027-03-19 | 2027-04-15 | 194 | P. Sundaram |
| 196 | 5.1.5 | Functional defect triage & retest | 20d | 2027-04-16 | 2027-05-13 | 195 | R. Whitfield |
| 197 | 5.2 | **System Testing (end-to-end)** | 15d | 2027-05-14 | 2027-06-03 | 190 |  |
| 198 | 5.2.1 | System test planning & environment setup | 2d | 2027-05-14 | 2027-05-17 |  | R. Whitfield |
| 199 | 5.2.2 | End-to-end scenarios — enrollment to claims | 4d | 2027-05-18 | 2027-05-21 | 198 | R. Whitfield |
| 200 | 5.2.3 | End-to-end scenarios — billing to payment | 4d | 2027-05-24 | 2027-05-27 | 199 | R. Whitfield |
| 201 | 5.2.4 | End-to-end scenarios — reporting | 3d | 2027-05-28 | 2027-06-01 | 200 | R. Whitfield |
| 202 | 5.2.5 | System test defect triage | 2d | 2027-06-02 | 2027-06-03 | 201 | R. Whitfield |
| 203 | 5.2A | **Security & Penetration Testing** | 5d | 2027-06-04 | 2027-06-10 | 197 |  |
| 204 | 5.2A.1 | External penetration test (vendor-conducted) | 3d | 2027-06-04 | 2027-06-08 |  | R. Whitfield |
| 205 | 5.2A.2 | Vulnerability remediation & retest | 1d | 2027-06-09 | 2027-06-09 | 204 | M. Alvarez |
| 206 | 5.2A.3 | Security sign-off (Compliance/Legal) | 1d | 2027-06-10 | 2027-06-10 | 205 | N. Sharma |
| 207 | 5.2B | **Performance & Load Testing (System-Wide)** | 5d | 2027-06-11 | 2027-06-17 | 203 |  |
| 208 | 5.2B.1 | Define load profiles & performance targets | 1d | 2027-06-11 | 2027-06-11 |  | R. Whitfield |
| 209 | 5.2B.2 | Execute full-volume load test across platform & integrations | 3d | 2027-06-14 | 2027-06-16 | 208 | M. Alvarez |
| 210 | 5.2B.3 | Analyze results & tune performance bottlenecks | 1d | 2027-06-17 | 2027-06-17 | 209 | M. Alvarez |
| 211 | 5.2C | **Disaster Recovery / Failover Testing** | 3d | 2027-06-18 | 2027-06-22 | 207 |  |
| 212 | 5.2C.1 | Execute planned failover to DR environment | 1d | 2027-06-18 | 2027-06-18 |  | M. Alvarez |
| 213 | 5.2C.2 | Validate system functionality & data integrity on DR | 1d | 2027-06-21 | 2027-06-21 | 212 | R. Whitfield |
| 214 | 5.2C.3 | Failback to primary & DR test sign-off | 1d | 2027-06-22 | 2027-06-22 | 213 | M. Alvarez |

| ID | WBS | Task | Duration | Start | Finish | Predecessors | Resources |
| --- | --- | --- | --- | --- | --- | --- | --- |
| 215 | 5.2D | **SOX Compliance Testing & Sign-off** | 5d | 2027-06-23 | 2027-06-29 | 211 |  |
| 216 | 5.2D.1 | Execute testing of updated SOX-relevant controls | 3d | 2027-06-23 | 2027-06-25 |  | G. Fenwick |
| 217 | 5.2D.2 | Internal Audit review of control testing results | 1d | 2027-06-28 | 2027-06-28 | 216 | G. Fenwick |
| 218 | 5.2D.3 | Formal SOX compliance sign-off | 1d | 2027-06-29 | 2027-06-29 | 217 | G. Fenwick |
| 219 | 5.3 | **Defect Remediation Cycle** | 10d | 2027-06-30 | 2027-07-13 | 215 |  |
| 220 | 5.3.1 | Prioritize defects (severity/priority) | 1d | 2027-06-30 | 2027-06-30 |  | R. Whitfield |
| 221 | 5.3.2 | Development fixes — critical/high defects | 5d | 2027-07-01 | 2027-07-07 | 220 | R. Whitfield |
| 222 | 5.3.3 | Regression retest of fixes | 3d | 2027-07-08 | 2027-07-12 | 221 | R. Whitfield |
| 223 | 5.3.4 | Defect closure sign-off | 1d | 2027-07-13 | 2027-07-13 | 222 | R. Whitfield |
| 224 | 5.4 | **User Acceptance Testing (UAT)** | 15d | 2027-07-14 | 2027-08-03 | 219 |  |
| 225 | 5.4.1 | UAT planning & test script development | 3d | 2027-07-14 | 2027-07-16 |  | R. Whitfield |
| 226 | 5.4.2 | UAT execution — Underwriting & New Business | 3d | 2027-07-19 | 2027-07-21 | 225 | R. Whitfield |
| 227 | 5.4.3 | UAT execution — Claims Administration | 3d | 2027-07-22 | 2027-07-26 | 226 | R. Whitfield |
| 228 | 5.4.4 | UAT execution — Billing & Payments | 3d | 2027-07-27 | 2027-07-29 | 227 | R. Whitfield |
| 229 | 5.4.5 | UAT defect triage & fixes | 3d | 2027-07-30 | 2027-08-03 | 228 | R. Whitfield |
| 230 | 5.5 | **UAT Sign-off** | 5d | 2027-08-04 | 2027-08-10 | 224 |  |
| 231 | 5.5.1 | Consolidate UAT results | 1d | 2027-08-04 | 2027-08-04 |  | R. Whitfield |
| 232 | 5.5.2 | Business stakeholder review | 2d | 2027-08-05 | 2027-08-06 | 231 | R. Whitfield |
| 233 | 5.5.3 | Formal UAT sign-off (Go/No-Go input) | 2d | 2027-08-09 | 2027-08-10 | 232 | R. Whitfield |
| 234 | 6 | **Cutover & Hypercare** | 60d | 2027-08-11 | 2027-11-02 | 189 |  |
| 235 | 6.1 | **Cutover Planning & Rehearsal** | 5d | 2027-08-11 | 2027-08-17 |  |  |
| 236 | 6.1.1 | Develop detailed cutover runbook | 2d | 2027-08-11 | 2027-08-12 |  | C. Tyrrell |
| 237 | 6.1.2 | Cutover rehearsal (dry run) | 2d | 2027-08-13 | 2027-08-16 | 236 | C. Tyrrell |
| 238 | 6.1.3 | Go/No-Go readiness review | 1d | 2027-08-17 | 2027-08-17 | 237 | C. Tyrrell |

| ID | WBS | Task | Duration | Start | Finish | Predecessors | Resources |
| --- | --- | --- | --- | --- | --- | --- | --- |
| 239 | 6.2 | **Go-Live / Production Cutover** | 5d | 2027-08-18 | 2027-08-24 | 235 |  |
| 240 | 6.2.1 | Final data conversion to production | 1d | 2027-08-18 | 2027-08-18 |  | C. Tyrrell |
| 241 | 6.2.2 | Production deployment — platform & integrations | 2d | 2027-08-19 | 2027-08-20 | 240 | C. Tyrrell |
| 242 | 6.2.3 | Post-deployment smoke testing | 1d | 2027-08-23 | 2027-08-23 | 241 | C. Tyrrell |
| 243 | 6.2.4 | Go-live communication & business sign-off | 1d | 2027-08-24 | 2027-08-24 | 242 | C. Tyrrell |
| 244 | 6.3 | **Hypercare / Stabilization Monitoring** | 15d | 2027-08-25 | 2027-09-14 | 239 |  |
| 245 | 6.3.1 | Daily production monitoring & issue triage | 10d | 2027-08-25 | 2027-09-07 |  | C. Tyrrell |
| 246 | 6.3.2 | Priority defect fixes during hypercare | 3d | 2027-09-08 | 2027-09-10 | 245 | C. Tyrrell |
| 247 | 6.3.3 | Hypercare exit readiness review | 2d | 2027-09-13 | 2027-09-14 | 246 | C. Tyrrell |
| 248 | 6.3B | **Post-Go-Live Customer Experience Monitoring & Feedback Collection** | 30d | 2027-08-25 | 2027-10-05 |  |  |
| 249 | 6.3B.1 | Monitor customer satisfaction & support ticket sentiment | 27d | 2027-08-25 | 2027-09-30 |  | V. Alaoui |
| 250 | 6.3B.2 | Consolidate CX feedback & report to Steering Committee | 3d | 2027-10-01 | 2027-10-05 | 249 | V. Alaoui |
| 251 | 6.4 | **Warranty Support Period (3-Week Vendor Warranty)** | 15d | 2027-09-15 | 2027-10-05 |  |  |
| 252 | 6.4.1 | Vendor warranty support activation & SLA confirmation | 1d | 2027-09-15 | 2027-09-15 |  | W. Donnelly |
| 253 | 6.4.2 | Ongoing defect monitoring under vendor warranty | 10d | 2027-09-16 | 2027-09-29 | 252 | M. Alvarez |
| 254 | 6.4.3 | Warranty-period defect resolution tracking | 3d | 2027-09-30 | 2027-10-04 | 253 | W. Donnelly |
| 255 | 6.4.4 | Warranty exit review & sign-off | 1d | 2027-10-05 | 2027-10-05 | 254 | C. Tyrrell |
| 256 | 6.5 | **Legacy System Decommissioning** | 10d | 2027-10-06 | 2027-10-19 | 251 |  |
| 257 | 6.5.1 | Confirm data retention requirements & archive legacy data | 4d | 2027-10-06 | 2027-10-11 |  | T. McCormick |
| 258 | 6.5.2 | Terminate legacy vendor licenses & contracts | 2d | 2027-10-12 | 2027-10-13 | 257 | W. Donnelly |
| 259 | 6.5.3 | Decommission legacy infrastructure/environment | 3d | 2027-10-14 | 2027-10-18 | 258 | M. Alvarez |
| 260 | 6.5.4 | Decommissioning sign-off (Compliance/Legal) | 1d | 2027-10-19 | 2027-10-19 | 259 | N. Sharma |
| 261 | 6.6 | **Production Support Transition** | 5d | 2027-10-20 | 2027-10-26 | 256 |  |
| 262 | 6.6.1 | Finalize support runbooks & knowledge base | 2d | 2027-10-20 | 2027-10-21 |  | M. Alvarez |
| 263 | 6.6.2 | Knowledge transfer sessions with Production Support team | 2d | 2027-10-22 | 2027-10-25 | 262 | E. Kowalski |
| 264 | 6.6.3 | Formal handover & Production Support acceptance sign-off | 1d | 2027-10-26 | 2027-10-26 | 263 | C. Tyrrell |

| ID | WBS | Task | Duration | Start | Finish | Predecessors | Resources |
| --- | --- | --- | --- | --- | --- | --- | --- |
| 265 | 6.7 | **Project Closeout & Lessons Learned** | 5d | 2027-10-27 | 2027-11-02 | 261 |  |
| 266 | 6.7.1 | Finalize project documentation & handover to support | 2d | 2027-10-27 | 2027-10-28 |  | C. Tyrrell |
| 267 | 6.7.2 | Lessons learned session | 1d | 2027-10-29 | 2027-10-29 | 266 | C. Tyrrell |
| 268 | 6.7.3 | Formal project closure & sign-off | 2d | 2027-11-01 | 2027-11-02 | 267 | C. Tyrrell |
| 269 | 7 | **Change Management & Training** | 240d | 2026-09-16 | 2027-08-17 |  |  |
| 270 | 7.1 | **Stakeholder Impact Assessment** | 10d | 2026-09-16 | 2026-09-29 |  |  |
| 271 | 7.1.1 | Identify impacted roles & workflows | 4d | 2026-09-16 | 2026-09-21 |  | L. Bergström |
| 272 | 7.1.2 | Assess change readiness by department | 4d | 2026-09-22 | 2026-09-25 | 271 | L. Bergström |
| 273 | 7.1.3 | Document impact assessment findings | 2d | 2026-09-28 | 2026-09-29 | 272 | L. Bergström |
| 274 | 7.2 | **Communication Plan Development** | 10d | 2026-09-30 | 2026-10-13 | 270 |  |
| 275 | 7.2.1 | Define communication audiences & channels | 3d | 2026-09-30 | 2026-10-02 |  | L. Bergström |
| 276 | 7.2.2 | Build communication calendar & key messages | 4d | 2026-10-05 | 2026-10-08 | 275 | L. Bergström |
| 277 | 7.2.3 | Sponsor review & approval | 3d | 2026-10-09 | 2026-10-13 | 276 | L. Bergström |
| 278 | 7.3 | **Training Needs Analysis** | 10d | 2027-03-17 | 2027-03-30 |  |  |
| 279 | 7.3.1 | Assess role-based training requirements | 5d | 2027-03-17 | 2027-03-23 |  | H. Osei |
| 280 | 7.3.2 | Define training delivery approach (in-person/virtual) | 3d | 2027-03-24 | 2027-03-26 | 279 | H. Osei |
| 281 | 7.3.3 | Finalize training curriculum outline | 2d | 2027-03-29 | 2027-03-30 | 280 | H. Osei |
| 282 | 7.4 | **Training Material Development** | 20d | 2027-03-31 | 2027-04-27 | 278 |  |
| 283 | 7.4.1 | Develop Underwriting & New Business training materials | 5d | 2027-03-31 | 2027-04-06 |  | H. Osei |
| 284 | 7.4.2 | Develop Claims Administration training materials | 5d | 2027-04-07 | 2027-04-13 | 283 | H. Osei |
| 285 | 7.4.3 | Develop Billing & Payments training materials | 5d | 2027-04-14 | 2027-04-20 | 284 | H. Osei |
| 286 | 7.4.4 | Develop Compliance & Customer Service training materials | 5d | 2027-04-21 | 2027-04-27 | 285 | H. Osei |
| 287 | 7.5 | **End-User Training Delivery** | 15d | 2027-06-16 | 2027-07-06 |  |  |
| 288 | 7.5.1 | Train Underwriting & New Business users | 3d | 2027-06-16 | 2027-06-18 |  | H. Osei |
| 289 | 7.5.2 | Train Claims Administration users | 3d | 2027-06-21 | 2027-06-23 | 288 | H. Osei |
| 290 | 7.5.3 | Train Billing & Payments users | 3d | 2027-06-24 | 2027-06-28 | 289 | H. Osei |
| 291 | 7.5.4 | Train Compliance & Customer Service users | 3d | 2027-06-29 | 2027-07-01 | 290 | H. Osei |
| 292 | 7.5.5 | Training feedback collection & reinforcement sessions | 3d | 2027-07-02 | 2027-07-06 | 291 | H. Osei |

| ID | WBS | Task | Duration | Start | Finish | Predecessors | Resources |
| --- | --- | --- | --- | --- | --- | --- | --- |
| 293 | 7.6 | **Go-Live Readiness Communications** | 5d | 2027-07-14 | 2027-07-20 |  |  |
| 294 | 7.6.1 | Send go-live readiness notices to end users | 2d | 2027-07-14 | 2027-07-15 |  | L. Bergström |
| 295 | 7.6.2 | Publish quick-reference guides & FAQs | 3d | 2027-07-16 | 2027-07-20 | 294 | L. Bergström |
| 296 | 7.6B | **External Customer Communications for Go-Live** | 5d | 2027-07-14 | 2027-07-20 |  |  |
| 297 | 7.6B.1 | Draft customer-facing notices (portal, billing, statements) | 3d | 2027-07-14 | 2027-07-16 |  | V. Alaoui |
| 298 | 7.6B.2 | Distribute customer communications & update self-service channels | 2d | 2027-07-19 | 2027-07-20 | 297 | V. Alaoui |
| 299 | 7.7 | **Post-Go-Live Support Desk Setup** | 20d | 2027-07-21 | 2027-08-17 | 296 |  |
| 300 | 7.7.1 | Staff & train hypercare support desk | 5d | 2027-07-21 | 2027-07-27 |  | H. Osei |
| 301 | 7.7.2 | Operate support desk during hypercare | 15d | 2027-07-28 | 2027-08-17 | 300 | H. Osei |
| 302 | 8 | **Program Governance & Risk Management** | 260d | 2026-08-19 | 2027-08-17 |  |  |
| 303 | 8.1 | **Program Reporting & Steering Committee** | 260d | 2026-08-19 | 2027-08-17 |  |  |
| 304 | 8.1.1 | Establish steering committee & reporting cadence | 5d | 2026-08-19 | 2026-08-25 |  | E. Kowalski |
| 305 | 8.1.2 | Weekly project status reporting | 250d | 2026-08-26 | 2027-08-10 | 304 | E. Kowalski |
| 306 | 8.1.3 | Monthly steering committee reviews | 250d | 2026-08-26 | 2027-08-10 |  | E. Kowalski |
| 307 | 8.2 | **Risk & Issue Management** | 260d | 2026-08-19 | 2027-08-17 |  |  |
| 308 | 8.2.1 | Establish risk register & escalation process | 5d | 2026-08-19 | 2026-08-25 |  | E. Kowalski |
| 309 | 8.2.2 | Ongoing risk & issue tracking | 245d | 2026-09-02 | 2027-08-10 |  | E. Kowalski |
| 310 | 8.2.3 | Monthly risk mitigation plan reviews | 245d | 2026-09-02 | 2027-08-10 |  | E. Kowalski |
| 311 | 8.3 | **Budget & Resource Management** | 258d | 2026-08-19 | 2027-08-13 |  |  |
| 312 | 8.3.1 | Build resource plan & staffing model | 10d | 2026-08-19 | 2026-09-01 |  | E. Kowalski |
| 313 | 8.3.1B | Establish Cost Baseline & Steering Committee Approval | 3d | 2026-09-02 | 2026-09-04 | 312 | E. Kowalski |
| 314 | 8.3.2 | Ongoing budget tracking & variance reporting | 245d | 2026-09-07 | 2027-08-13 | 313 | E. Kowalski |
| 315 | 8.3.3 | Vendor invoice management & reconciliation | 220d | 2026-10-05 | 2027-08-06 |  | W. Donnelly |
